# gant

Schedule from MS Project, 2008-08-18 to 2008-12-08, 4 hours a day, costs in $, A marks actual dates.

## Calendars

- Standard: Mon-Fri 09:30-11:30, 14:30-16:30; Sat-Sun off.

## Resources

| Resource | Group | Rate |
| --- | --- | --- |
| Emanuel | All | 46.2 |
| Arnaldo | All | 25.07 |
| Raul | All | 25.24 |
| Antonio | All | 25.24 |
| All |  |  |
| Antoniol |  |  |

## Schedule

| ID | WBS | Task | Duration | Start | Finish | Predecessors | Complete | Baseline start | Baseline finish | Baseline duration | Constraint | Deadline | Resources | Work | Actual work | Cost | Baseline cost | Actual cost |
| --- | --- | --- | --- | --- | --- | --- | --- | --- | --- | --- | --- | --- | --- | --- | --- | --- | --- | --- |
| 1 | 1 | **WBS** | 81d? | 2008-08-18 A | 2008-12-08 A |  | 100% | 2008-08-18 | 2008-12-08 | 81d? |  |  |  | 1520h | 1520h | 35,179.08 | 42,085.28 | 35,179.08 |
| 2 | 1.1 | **Reports & Presentations** | 81d? | 2008-08-18 A | 2008-12-08 A |  | 100% | 2008-08-18 | 2008-12-01 | 76d? |  |  |  | 324h | 324h |  |  |  |
| 3 | 1.1.1 | Project Proposal | 18d? | 2008-08-18 A | 2008-09-10 A |  | 100% | 2008-08-18 | 2008-09-10 | 18d? | start no earlier than 2008-08-18 | 2008-09-10 | All | 72h | 72h |  |  |  |
| 4 | 1.1.2 | Progress Report | 35d? | 2008-09-11 A | 2008-10-29 A | 3 | 100% | 2008-09-11 | 2008-10-29 | 35d? | start no earlier than 2008-09-11 |  | All | 140h | 140h |  |  |  |
| 5 | 1.1.3 | Final Report | 28d? | 2008-10-30 A | 2008-12-08 A | 4 | 100% | 2008-10-30 | 2008-12-01 | 23d? | finish no earlier than 2008-12-08 |  | All | 112h | 112h |  |  |  |
| 6 | 1.2 | **DB-MARC** | 56d? | 2008-09-15 A | 2008-12-01 A |  | 100% | 2008-09-15 | 2008-11-11 | 41.5d? |  |  |  | 296h | 296h | 7,471.04 | 8,163.04 | 7,471.04 |
| 7 | 1.2.1 | Design: ER Diagram | 10d? | 2008-09-15 A | 2008-09-26 A |  | 100% | 2008-09-15 | 2008-09-26 | 10d? | start no earlier than 2008-09-15 |  | Antonio | 40h | 40h | 1,009.6 | 1,009.6 | 1,009.6 |
| 8 | 1.2.2 | MySQL Implementation & Structure | 10d? | 2008-09-29 A | 2008-10-10 A | 7 | 100% | 2008-09-29 | 2008-10-10 | 10d? |  |  | Antonio | 40h | 40h | 1,009.6 | 1,009.6 | 1,009.6 |
| 9 | 1.2.3 | MARC Understanding | 18d? | 2008-10-15 A | 2008-11-07 A |  | 100% |  |  |  | finish no earlier than 2008-11-07 |  | Antonio | 72h | 72h | 1,817.28 |  | 1,817.28 |
| 10 | 1.2.4 | MARC-DB Adjustments | 5d? | 2008-11-10 A | 2008-11-14 A | 9 | 100% |  |  |  | finish no earlier than 2008-11-18 |  | Antonio | 20h | 20h | 504.8 |  | 504.8 |
| 11 | 1.2.5 | Queries 1: Records Insertion | 5d? | 2008-11-17 A | 2008-11-21 A | 10 | 100% | 2008-10-13 | 2008-10-28 | 11.5d? | start no earlier than 2008-11-17 |  | Antonio | 20h | 20h | 504.8 | 3,286.24 | 504.8 |
| 12 | 1.2.6 | Queries 2: Station Management | 5d? | 2008-11-20 A | 2008-11-26 A | 10 | 100% |  |  |  | finish no earlier than 2008-11-26 |  | Antonio | 20h | 20h | 504.8 |  | 504.8 |
| 13 | 1.2.7 | Transactions Management | 4d? | 2008-11-21 A | 2008-11-26 A | 10 | 100% |  |  |  | finish no earlier than 2008-11-27 |  | Antonio | 16h | 16h | 403.84 |  | 403.84 |
| 14 | 1.2.8 | Database Filling | 3d? | 2008-11-19 A | 2008-11-21 A | 10 | 100% |  |  |  | finish no earlier than 2008-11-21 |  | Antonio | 12h | 12h | 302.88 |  | 302.88 |
| 15 | 1.2.9 | Tags Management | 5d? | 2008-11-18 A | 2008-11-24 A | 10 | 100% |  |  |  | finish no earlier than 2008-11-24 |  | Antonio | 20h | 20h | 504.8 |  | 504.8 |
| 16 | 1.2.10 | MARC Packet Management | 3d? | 2008-11-24 A | 2008-11-26 A | 10 | 100% |  |  |  | finish no earlier than 2008-11-26 |  | Antonio | 12h | 12h | 302.88 |  | 302.88 |
| 17 | 1.2.11 | Testing | 6d? | 2008-11-24 A | 2008-12-01 A | 11, 14 | 100% | 2008-10-28 | 2008-11-11 | 10d? | finish no earlier than 2008-11-26 |  | Antonio | 24h | 24h | 605.76 | 2,857.6 | 605.76 |
| 18 | 1.3 | **Station** | 41d? | 2008-10-02 A | 2008-11-27 A | 3 | 100% | 2008-10-02 | 2008-11-25 | 38.5d? |  |  |  | 360h | 360h | 12,611.96 | 5,542.48 | 12,611.96 |
| 19 | 1.3.1 | USB DataAcquisition | 16d? | 2008-10-22 A | 2008-11-12 A |  | 100% | 2008-10-22 | 2008-11-04 | 10d? | finish no earlier than 2008-11-12 |  | Emanuel | 64h | 64h | 2,956.8 | 2,019.2 | 2,956.8 |
| 20 | 1.3.2 | Station redesigned | 13d? | 2008-10-22 A | 2008-11-07 A |  | 100% |  |  |  | finish no earlier than 2008-11-07 |  | Raul | 52h | 52h | 1,312.48 |  | 1,312.48 |
| 21 | 1.3.3 | Functionality redefinition | 1d? | 2008-11-05 A | 2008-11-05 A |  | 100% |  |  |  |  |  | All | 4h | 4h |  |  |  |
| 22 | 1.3.4 | Serial Communication package adaptation | 2d? | 2008-11-13 A | 2008-11-14 A | 19 | 100% |  |  |  | start no earlier than 2008-11-13 |  | Raul | 8h | 8h | 201.92 |  | 201.92 |
| 23 | 1.3.5 | Data Interpretation | 7d? | 2008-11-13 A | 2008-11-21 A | 19, 40 | 100% | 2008-11-18 | 2008-11-20 | 2.5d? | finish no earlier than 2008-11-21 |  | Emanuel | 28h | 28h | 1,293.6 | 252.4 | 1,293.6 |
| 24 | 1.3.6 | Design & Layout | 6.5d? | 2008-10-02 A | 2008-10-10 A |  | 100% | 2008-10-02 | 2008-10-10 | 6.5d? | start no earlier than 2008-10-02 |  | Raul; Emanuel | 52h | 52h | 1,857.44 | 1,857.44 | 1,857.44 |
| 25 | 1.3.7 | User ID Permanence | 6d | 2008-11-17 A | 2008-11-24 A | 41 | 100% | 2008-11-18 | 2008-11-25 | 6d | finish no earlier than 2008-11-24 |  | Emanuel; Raul | 48h | 48h | 1,714.56 | 601.68 | 1,714.56 |
| 26 | 1.3.8 | Server Management | 6d? | 2008-11-19 A | 2008-11-26 A | 19 | 100% |  |  |  | finish no earlier than 2008-11-26 |  | Emanuel | 24h | 24h | 1,108.8 |  | 1,108.8 |
| 27 | 1.3.9 | Client Management | 8d? | 2008-11-17 A | 2008-11-26 A | 19, 21 | 100% | 2008-10-22 | 2008-11-07 | 12.5d? | finish no earlier than 2008-11-26 |  | Raul | 32h | 32h | 807.68 |  | 807.68 |
| 28 | 1.3.10 | Client-Server Integration-Testing | 3d? | 2008-11-24 A | 2008-11-26 A |  | 100% |  |  |  | finish no earlier than 2008-11-26 |  | Emanuel; Raul | 24h | 24h | 857.28 |  | 857.28 |
| 29 | 1.3.11 | Email sender for check-in/check-out | 2d? | 2008-11-25 A | 2008-11-26 A | 23 | 100% |  |  |  | start no earlier than 2008-11-25 |  | Arnaldo | 8h | 8h | 200.56 |  | 200.56 |
| 30 | 1.3.12 | Beans Modification | 3d? | 2008-11-19 A | 2008-11-21 A | 10 | 100% |  |  |  | finish no earlier than 2008-11-21 |  | Arnaldo | 12h | 12h | 300.84 |  | 300.84 |
| 31 | 1.3.13 | Station Final Testing | 1d? | 2008-11-27 A | 2008-11-27 A | 23, 19, 27 | 100% | 2008-11-20 | 2008-11-25 | 3d? | finish no earlier than 2008-11-27 |  | All | 4h | 4h |  |  |  |

| ID | WBS | Task | Duration | Start | Finish | Predecessors | Complete | Baseline start | Baseline finish | Baseline duration | Constraint | Resources | Work | Actual work | Cost | Baseline cost | Actual cost |
| --- | --- | --- | --- | --- | --- | --- | --- | --- | --- | --- | --- | --- | --- | --- | --- | --- | --- |
| 32 | 1.4 | **Remote Access** | 22d? | 2008-09-11 A | 2008-10-10 A | 3 | 100% | 2008-09-11 | 2008-11-18 | 49d? |  |  | 236h | 236h | 7,675.36 | 20,959.04 | 7,675.36 |
| 33 | 1.4.1 | Web Application General Design | 5.5d? | 2008-09-11 A | 2008-09-18 A |  | 100% | 2008-09-11 | 2008-09-18 | 5.5d? |  | Raul; Emanuel | 44h | 44h | 1,571.68 | 1,571.68 | 1,571.68 |
| 34 | 1.4.2 | Employee Management | 16.5d? | 2008-09-18 A | 2008-10-10 A | 33 | 100% | 2008-09-18 | 2008-10-10 | 16.5d? |  | Raul | 66h | 66h | 1,665.84 | 1,665.84 | 1,665.84 |
| 35 | 1.4.3 | Customer Management | 16.5d? | 2008-09-18 A | 2008-10-10 A | 33 | 100% | 2008-09-18 | 2008-10-10 | 16.5d? |  | Raul | 66h | 66h | 1,665.84 | 1,665.84 | 1,665.84 |
| 36 | 1.4.4 | Beans Creation | 15d? | 2008-09-22 A | 2008-10-10 A | 33 | 100% | 2008-09-22 | 2008-10-10 | 15d? | start no earlier than 2008-09-22 | Emanuel | 60h | 60h | 2,772 | 2,772 | 2,772 |
| 37 | 1.5 | **Hardware Prototype** | 51d? | 2008-09-15 A | 2008-11-24 A | 3 | 100% | 2008-09-15 | 2008-11-25 | 52d? |  |  | 296h | 296h | 7,420.72 | 7,420.72 | 7,420.72 |
| 38 | 1.5.1 | USB Module Integration | 5d? | 2008-09-22 A | 2008-09-26 A |  | 100% | 2008-09-22 | 2008-09-26 | 5d? | finish no earlier than 2008-09-26 | Arnaldo | 20h | 20h | 501.4 | 501.4 | 501.4 |
| 39 | 1.5.2 | RFID Module Integration | 8d? | 2008-09-15 A | 2008-09-24 A |  | 100% | 2008-09-15 | 2008-09-24 | 8d? | finish no earlier than 2008-09-24 | Arnaldo | 32h | 32h | 802.24 | 802.24 | 802.24 |
| 40 | 1.5.3 | Redirect power from USB port | 18d? | 2008-10-15 A | 2008-11-07 A | 38, 39 | 100% | 2008-10-15 | 2008-11-07 | 18d? | finish no earlier than 2008-10-27 | Arnaldo | 72h | 72h | 1,805.04 | 1,805.04 | 1,805.04 |
| 41 | 1.5.4 | USB Data Acquisition | 5d? | 2008-11-10 A | 2008-11-14 A | 40 | 100% | 2008-11-10 | 2008-11-17 | 6d? | start no earlier than 2008-10-28 | Arnaldo | 20h | 20h | 501.4 | 601.68 | 501.4 |
| 42 | 1.5.5 | Scanning Process | 8d? | 2008-09-15 A | 2008-09-24 A |  | 100% | 2008-09-15 | 2008-09-24 | 8d? | finish no earlier than 2008-09-24 | Arnaldo | 32h | 32h | 802.24 | 802.24 | 802.24 |
| 43 | 1.5.6 | Prototype 1 Assembly | 20d? | 2008-09-15 A | 2008-10-10 A |  | 100% | 2008-09-15 | 2008-10-10 | 20d? | finish no earlier than 2008-10-10 | Arnaldo | 80h | 80h | 2,005.6 | 2,005.6 | 2,005.6 |
| 44 | 1.5.7 | Prototype 1 Testing | 3d? | 2008-10-13 A | 2008-10-15 A | 43 | 100% | 2008-10-13 | 2008-10-15 | 3d? | finish no earlier than 2008-10-15 | Arnaldo | 12h | 12h | 300.84 | 300.84 | 300.84 |
| 45 | 1.5.8 | Prototype 2 Assembly/Testing | 5d? | 2008-11-10 A | 2008-11-14 A | 40, 44 | 100% |  |  |  | start no earlier than 2008-11-10 | Arnaldo | 20h | 20h | 501.4 |  | 501.4 |
| 46 | 1.5.9 | Final Prototype | 2d? | 2008-11-21 A | 2008-11-24 A | 45 | 100% | 2008-11-03 | 2008-11-07 | 5d? | finish no earlier than 2008-11-24 | Arnaldo | 8h | 8h | 200.56 |  | 200.56 |
| 47 | 1.6 | Full System Testing | 2d? | 2008-11-28 A | 2008-12-01 A | 18, 6, 37 | 100% | 2008-12-01 | 2008-12-08 | 6d? | start no earlier than 2008-11-28 | All | 8h | 8h |  |  |  |
